# Colector Zona Centro VF

Schedule from MS Project, 2021-01-01 to 2023-09-01, costs in $.
El presente proyecto surge por la necesidad que tiene el distrito de Santa Marta en evacuar las escorrentías superficiales producto de fuertes precipitaciones, las cuales se encuentran enmarcados en su componente estratégico POI 2020-2023 en que proyectan la construcción de colectores de aguas lluvias. Para esto, se requiere evacuar las aguas de escorrentía superficial que transitan sobre la calle 22 entre las carreras 1 y 5, toda vez que en época de invierno se produce inundaciones sobre el mismo y parte del centro histórico, ya que no existe un sistema de alcantarillado pluvial que conduzca dichas aguas al mar Caribe. Dentro del componente estratégico de la Alcaldía Distrital de Santa Marta, se proyectan la construcción de 10 Km en colectores de aguas lluvias.

## Calendars

- Colector Zona Centro: Mon-Fri 08:00-12:00, 13:00-17:00; Sat-Sun off. Exceptions (off unless hours are given): 2021-01-01 (Festivo), 2021-01-11 (Festivo), 2021-03-22 (Festivo), 2021-04-01 to 2021-04-02 (Semana Santa), 2021-05-17 (Festivo), 2021-06-07 (Festivo), 2021-06-14 (Festivo), 2021-07-05 (Festivo), 2021-07-20 (Festivo), 2021-08-16 (Festivo), 2021-10-18 (Festivo), 2021-11-01 (Festivo), 2021-11-15 (Festivo), 2021-12-08 (Festivo).

## Resources

| Resource | Rate |
| --- | --- |
| Gerente del proyecto | 43750 |
| Ing. Civil Senior | 27083 |
| Ing. Suelos | 27083 |
| Ing. Hidráulico | 27083 |
| Ing. Civil | 27083 |
| Arq. Diseñador | 27083 |
| Cliente |  |
| Ing. Estructural | 27083 |
| Ing. Ambiental | 27083 |
| Trabajadora Social | 10416 |
| Secretaría | 6250 |
| Director de Obra | 20833 |
| Residente de Obra | 14583 |
| Coordinador de Adquisiciones | 27083 |
| Almacenista | 6250 |

## Schedule

| ID | WBS | Task | Type | Duration | Start | Finish | Predecessors | Baseline start | Baseline finish | Baseline duration | Total slack | Resources | Work | Cost |
| --- | --- | --- | --- | --- | --- | --- | --- | --- | --- | --- | --- | --- | --- | --- |
| 1 | 1 | **INICIO** |  | 0d | 2021-01-01 | 2021-01-01 |  | 2021-01-01 | 2021-01-01 | 0d | 0d |  |  |  |
| 2 | 1.1 | Inicio | milestone | 0d | 2021-01-01 | 2021-01-01 |  | 2021-01-01 | 2021-01-01 | 0d | 0d |  |  |  |
| 3 | 2 | **ELABORACIÓN DE ESTUDIOS Y DISEÑOS PARA EL COLECTOR DE AGUAS LLUVIAS, TRAMO COMPRENDIDO SOBRE LA CALLE 22 ENTRE LAS CARRERAS 1 Y 5 DEL MUNICIPIO DE SANTA MARTA D.T.C.H, DEPARTAMENTO DEL MAGDALENA** |  | 323d | 2021-01-04 | 2022-04-19 |  | 2021-01-04 | 2022-04-19 | 323d | 0d |  | 4755h | 267,902,778 |
| 4 | 2.1 | **FASE DIAGNÓSTICO** |  | 38d | 2021-01-04 | 2021-02-25 |  | 2021-01-04 | 2021-02-25 | 38d | 0d |  | 419h | 26,869,444 |
| 5 | 2.1.1 | Estudio de Población y Demanda |  | 7d | 2021-01-04 | 2021-01-13 | 2 | 2021-01-04 | 2021-01-13 | 7d | 0d | Gerente del proyecto; Ing. Civil; Ing. Civil Senior | 129h | 6,664,583 |
| 6 | 2.1.2 | Balance de la Oferta y la Demanda |  | 5d | 2021-01-07 | 2021-01-14 | 5SS+3d | 2021-01-07 | 2021-01-14 | 5d | 0d | Ing. Civil; Ing. Civil Senior | 37h | 3,406,250 |
| 7 | 2.1.3 | Elaboración de catastro de redes de acueducto y censo de usuarios |  | 10d | 2021-01-07 | 2021-01-21 | 6SS | 2021-01-07 | 2021-01-21 | 10d | 0d | Ing. Civil | 53h | 3,611,111 |
| 8 | 2.1.4 | Levantamiento de información detallada de las características de la zona rural en caso que el trazado del proyecto pase por alguna vereda y de los barrios priorizados |  | 10d | 2021-01-22 | 2021-02-04 | 7 | 2021-01-22 | 2021-02-04 | 10d | 0d | Ing. Civil Senior | 80h | 4,375,000 |
| 9 | 2.1.5 | Realizar un análisis de las zonas de expansión según planes de ordenamiento territorial, proyecciones de población y determinación de caudales para el horizonte del proyecto |  | 15d | 2021-02-05 | 2021-02-25 | 8 | 2021-02-05 | 2021-02-25 | 15d | 0d | Ing. Civil | 120h | 8,812,500 |
| 10 | 2.2 | **ESTUDIOS TÉCNICOS Y AMBIENTALES** |  | 111d | 2021-02-26 | 2021-08-11 |  | 2021-02-26 | 2021-08-11 | 111d | 0d |  | 1080h | 86,927,084 |
| 11 | 2.2.1 | Realizar los levantamientos topográficos geodésicos y altimétricos |  | 8d | 2021-02-26 | 2021-03-09 | 9 | 2021-02-26 | 2021-03-09 | 8d | 0d | Ing. Civil Senior | 64h | 3,666,667 |
| 12 | 2.2.2 | Estudios de sobrevuelos con Drones RTK-4 y generación de las ortofotos |  | 7d | 2021-03-04 | 2021-03-12 | 11SS+4d | 2021-03-04 | 2021-03-12 | 7d | 0d | Ing. Civil | 56h | 4,958,333 |
| 13 | 2.2.3 | Estudios hidrológicos e/o hidrogeológicos |  | 20d | 2021-03-15 | 2021-04-14 | 12 | 2021-03-15 | 2021-04-14 | 20d | 0d | Ing. Hidráulico | 160h | 10,291,667 |
| 14 | 2.2.4 | Estudios Suelos, Geotécnicos, Geológicos y Laboratorios pertinentes para la estructuración de los componentes del sistema de acueducto que se requiere |  | 30d | 2021-03-15 | 2021-04-28 | 13SS | 2021-03-15 | 2021-04-28 | 30d | 0d | Ing. Suelos | 240h | 15,437,500 |
| 15 | 2.2.5 | Estudios de Disponibilidad de Energía Eléctrica |  | 15d | 2021-04-29 | 2021-05-20 | 14 | 2021-04-29 | 2021-05-20 | 15d | 0d | Ing. Civil Senior | 120h | 10,625,000 |
| 16 | 2.2.6 | Estudios de Disponibilidad de Energía Alternativa |  | 12d | 2021-05-21 | 2021-06-08 | 15 | 2021-05-21 | 2021-06-08 | 12d | 0d | Ing. Civil Senior | 96h | 8,500,000 |
| 17 | 2.2.7 | Investigación Predial |  | 10d | 2021-06-09 | 2021-06-23 | 16 | 2021-06-09 | 2021-06-23 | 10d | 0d | Ing. Civil Senior | 80h | 6,916,667 |
| 18 | 2.2.8 | Elaboración de Estudios hidráulicos |  | 15d | 2021-06-24 | 2021-07-15 | 17 | 2021-06-24 | 2021-07-15 | 15d | 0d | Ing. Hidráulico | 120h | 16,781,250 |
| 19 | 2.2.9 | Actividades y Permisos Ambientales |  | 18d | 2021-07-16 | 2021-08-11 | 18 | 2021-07-16 | 2021-08-11 | 18d | 0d | Ing. Ambiental | 144h | 9,750,000 |
| 20 | 2.3 | **ANÁLISIS DE ALTERNATIVAS** |  | 33d | 2021-08-12 | 2021-09-28 |  | 2021-08-12 | 2021-09-28 | 33d | 0d |  | 960h | 30,687,500 |
| 21 | 2.3.1 | Elaboración del estudio de alternativas |  | 20d | 2021-08-12 | 2021-09-09 | 19 | 2021-08-12 | 2021-09-09 | 20d | 0d | Gerente del proyecto; Ing. Civil Senior | 320h | 25,000,000 |
| 22 | 2.3.2 | Selección de la Alternativa (concertación entre las partes) |  | 7d | 2021-09-10 | 2021-09-20 | 21 | 2021-09-10 | 2021-09-20 | 7d | 0d | Cliente; Gerente del proyecto | 112h | 3,062,500 |
| 23 | 2.3.3 | Socialización |  | 6d | 2021-09-21 | 2021-09-28 | 22 | 2021-09-21 | 2021-09-28 | 6d | 0d | Arq. Diseñador; Cliente; Gerente del proyecto; Ing. Ambiental; Ing. Civil; Ing. Civil Senior; Ing. Estructural; Ing. Hidráulico; Ing. Suelos; Secretaría; Trabajadora Social | 528h | 2,625,000 |
| 24 | 2.4 | **DISEÑOS DEFINITIVOS** |  | 111d | 2021-09-29 | 2022-03-08 |  | 2021-09-29 | 2022-03-08 | 111d | 0d |  | 1960h | 100,168,750 |
| 25 | 2.4.1 | Diseños hidráulicos |  | 15d | 2021-09-29 | 2021-10-20 | 23 | 2021-09-29 | 2021-10-20 | 15d | 0d | Ing. Hidráulico | 120h | 7,718,750 |
| 26 | 2.4.2 | Diseños estructurales |  | 15d | 2021-10-06 | 2021-10-27 | 25SS+5d | 2021-10-06 | 2021-10-27 | 15d | 0d | Ing. Estructural | 120h | 8,125,000 |
| 27 | 2.4.3 | Diseños eléctricos, electromecánicos e hidromecánico |  | 18d | 2021-10-28 | 2021-11-24 | 26 | 2021-10-28 | 2021-11-24 | 18d | 0d | Ing. Civil Senior | 144h | 17,137,500 |
| 28 | 2.4.4 | Diseños arquitectónicos |  | 20d | 2021-10-28 | 2021-11-26 | 27SS | 2021-10-28 | 2021-11-26 | 20d | 0d | Arq. Diseñador | 160h | 12,083,333 |
| 29 | 2.4.5 | Planos |  | 10d | 2021-11-29 | 2021-12-13 | 28 | 2021-11-29 | 2021-12-13 | 10d | 0d | Arq. Diseñador; Ing. Civil | 160h | 6,041,667 |
| 30 | 2.4.6 | Costos de operación y mantenimiento |  | 12d | 2021-12-14 | 2021-12-29 | 29 | 2021-12-14 | 2021-12-29 | 12d | 0d | Ing. Civil | 96h | 5,250,000 |
| 31 | 2.4.7 | Elaboración de análisis de precios unitarios, presupuestos de detalle y especificaciones técnicas, cronograma de ejecución de las obras, flujo de fondos e inversiones |  | 7d | 2021-12-30 | 2022-01-07 | 30 | 2021-12-30 | 2022-01-07 | 7d | 0d | Ing. Civil; Ing. Civil Senior | 112h | 6,125,000 |
| 32 | 2.4.8 | Especificaciones técnicas de construcción |  | 7d | 2022-01-10 | 2022-01-18 | 31 | 2022-01-10 | 2022-01-18 | 7d | 0d | Ing. Civil Senior | 28h | 3,062,500 |
| 33 | 2.4.9 | Descripción y elaboración del manual de operación, mantenimiento y puesta en marcha del sistema diseñado |  | 7d | 2022-01-10 | 2022-01-18 | 32SS | 2022-01-10 | 2022-01-18 | 7d | 0d | Ing. Civil; Ing. Civil Senior | 84h | 4,229,167 |
| 34 | 2.4.10 | Análisis de la vulnerabilidad del riesgo y plan de contingencias |  | 6d | 2022-01-19 | 2022-01-26 | 33 | 2022-01-19 | 2022-01-26 | 6d | 0d | Gerente del proyecto; Ing. Ambiental | 96h | 2,625,000 |
| 35 | 2.4.11 | Participación en las mesas técnicas a realizarse con la autoridad ambiental y demás entidades competentes con el objeto de discutir puntos específicos sobre el sistema |  | 10d | 2022-01-19 | 2022-02-01 | 34SS | 2022-01-19 | 2022-02-01 | 10d | 0d | Ing. Civil Senior | 80h | 10,833,333 |
| 36 | 2.4.12 | Plan de gestión social |  | 15d | 2022-02-02 | 2022-02-22 | 35 | 2022-02-02 | 2022-02-22 | 15d | 0d | Ing. Ambiental | 120h | 10,375,000 |
| 37 | 2.4.13 | Informe final de diseño |  | 10d | 2022-02-23 | 2022-03-08 | 36 | 2022-02-23 | 2022-03-08 | 10d | 0d | Arq. Diseñador; Gerente del proyecto; Ing. Ambiental; Ing. Civil; Ing. Civil Senior; Ing. Estructural; Ing. Hidráulico; Ing. Suelos | 640h | 6,562,500 |

| ID | WBS | Task | Duration | Start | Finish | Predecessors | Baseline start | Baseline finish | Baseline duration | Total slack | Free slack | Resources | Work | Cost |
| --- | --- | --- | --- | --- | --- | --- | --- | --- | --- | --- | --- | --- | --- | --- |
| 38 | 2.5 | **FORMULACIÓN DE PROYECTOS** | 30d | 2022-03-09 | 2022-04-19 |  | 2022-03-09 | 2022-04-19 | 30d | 0d |  |  | 336h | 23,250,000 |
| 39 | 2.5.1 | Documentos técnicos para la presentación del proyecto | 12d | 2022-03-09 | 2022-03-24 | 37 | 2022-03-09 | 2022-03-24 | 12d | 0d |  | Gerente del proyecto; Ing. Civil | 192h | 4,000,000 |
| 40 | 2.5.2 | Elaboración de las Fichas de la Metodología General Ajustada MGA y su respectivo documento técnico de soporte | 4d | 2022-03-25 | 2022-03-30 | 39 | 2022-03-25 | 2022-03-30 | 4d | 0d |  | Ing. Civil | 32h | 1,750,000 |
| 41 | 2.5.3 | Documentos de la entidad territorial que presenta el proyecto ante el MVCT | 7d | 2022-03-31 | 2022-04-08 | 40SS+4d | 2022-03-31 | 2022-04-08 | 7d | 0d |  | Ing. Civil | 56h | 8,750,000 |
| 42 | 2.5.4 | Ajustes al proyecto | 7d | 2022-04-11 | 2022-04-19 | 41 | 2022-04-11 | 2022-04-19 | 7d | 0d |  | Ing. Civil | 56h | 8,750,000 |
| 43 | 3 | **CONSTRUCCIÓN COLECTOR PLUVIAL DE LA CALLE 22 ENTRE LAS CARRERAS 1 Y 5, SANTA MARTA D.T.C.H.** | 358d | 2022-04-20 | 2023-09-01 |  | 2022-04-20 | 2023-09-01 | 358d | 0d |  |  | 7732h | 7,321,496,061 |
| 44 | 3.1 | **PRELIMINARES** | 30d | 2022-04-20 | 2022-05-31 |  | 2022-04-20 | 2022-05-31 | 30d | 0d |  |  | 720h | 18,125,000 |
| 45 | 3.1.1 | Trazado y Replanteo | 30d | 2022-04-20 | 2022-05-31 | 42 | 2022-04-20 | 2022-05-31 | 30d | 0d |  | Director de Obra; Residente de Obra; Coordinador de Adquisiciones | 720h | 18,125,000 |
| 46 | 3.2 | **PERFILADAS Y DEMOLICIONES** | 48d | 2022-06-01 | 2022-08-05 |  | 2022-06-01 | 2022-08-05 | 48d | 0d |  |  | 1005h | 127,110,000 |
| 47 | 3.2.1 | **PERFILACIONES** | 45d | 2022-06-01 | 2022-08-02 |  | 2022-06-01 | 2022-08-02 | 45d | 0d |  |  | 311h | 23,220,000 |
| 48 | 3.2.1.1 | Perfilada de Pavimento | 45d | 2022-06-01 | 2022-08-02 | 45 | 2022-06-01 | 2022-08-02 | 45d | 0d |  | Residente de Obra; Coordinador de Adquisiciones | 311h | 23,220,000 |
| 49 | 3.2.2 | **DEMOLICIÓN DE PAVIMENTO** | 45d | 2022-06-06 | 2022-08-05 |  | 2022-06-06 | 2022-08-05 | 45d | 0d |  |  | 694h | 103,890,000 |
| 50 | 3.2.2.1 | Demolición de Pavimentos con compresor manual (0.15 m< e < 0.25 m) | 45d | 2022-06-06 | 2022-08-05 | 48SS+3d | 2022-06-06 | 2022-08-05 | 45d | 0d |  | Residente de Obra; Trabajadora Social; Coordinador de Adquisiciones | 694h | 103,890,000 |
| 51 | 3.3 | **EXCAVACIONES Y ENTIBADO** | 90d | 2022-06-13 | 2022-10-14 |  | 2022-06-13 | 2022-10-14 | 90d | 0d |  |  | 1243h | 688,826,941 |
| 52 | 3.3.1 | Excavación a máquina en material común, roca descompuesta a cualquier | 90d | 2022-06-13 | 2022-10-14 | 50SS+5d | 2022-06-13 | 2022-10-14 | 90d | 0d |  | Director de Obra; Coordinador de Adquisiciones | 1243h | 688,826,941 |
| 53 | 3.4 | **RELLENOS** | 50d | 2023-02-01 | 2023-04-11 |  | 2023-02-01 | 2023-04-11 | 50d | 58d |  |  | 787h | 411,579,464 |
| 54 | 3.4.1 | Relleno de Zanja y obras de mampostería con Material Seleccionado del Sitio al 95% del P.M. | 45d | 2023-02-08 | 2023-04-11 | 55SS+5d | 2023-02-08 | 2023-04-11 | 45d | 58d | 0d | Director de Obra; Ing. Civil; Coordinador de Adquisiciones | 535h | 161,462,482 |
| 55 | 3.4.2 | Relleno de Zanja y obras de mampostería con Material Seleccionado de Cantera Tipo 2 0 3 al 95% del P.M. | 45d | 2023-02-01 | 2023-04-04 | 63SS | 2023-02-01 | 2023-04-04 | 45d | 58d | 0d | Director de Obra; Residente de Obra; Coordinador de Adquisiciones | 252h | 250,116,982 |
| 56 | 3.5 | **INSTALACIÓN Y SUMINISTRO TUBERÍAS Y ACCESORIOS ALCANTARILLADO (bajo cualquier condición de humedad, incluye accesorios)** | 77d | 2022-10-26 | 2023-02-09 |  | 2022-10-26 | 2023-02-09 | 77d | 58d |  |  | 582h | 658,351,446 |
| 57 | 3.5.1 | Instalación y Suministro de Tubería PVC NOVAFORT 200mm | 30d | 2022-10-26 | 2022-12-06 | 65SS+7d | 2022-10-26 | 2022-12-06 | 30d | 58d | 0d | Residente de Obra; Coordinador de Adquisiciones | 240h | 198,624,036 |
| 58 | 3.5.2 | Instalación y Suministro de Tubería PVC NOVAFORT 450mm | 45d | 2022-12-07 | 2023-02-07 | 57 | 2022-12-07 | 2023-02-07 | 45d | 58d | 0d | Residente de Obra; Coordinador de Adquisiciones | 209h | 308,447,900 |
| 59 | 3.5.3 | Instalación y Suministro de Tubería PVC NOVAFORT 500mm | 40d | 2022-12-16 | 2023-02-09 | 58SS+7d | 2022-12-16 | 2023-02-09 | 40d | 58d | 0d | Residente de Obra; Coordinador de Adquisiciones | 133h | 151,279,510 |
| 60 | 3.6 | **CONCRETOS** | 180d | 2022-10-17 | 2023-06-23 |  | 2022-10-17 | 2023-06-23 | 180d | 0d |  |  | 2490h | 3,306,085,902 |
| 61 | 3.6.1 | Pavimento en Concreto Rigido Reforzado MR 650 PSI e=0.3m | 45d | 2023-04-12 | 2023-06-13 | 54 | 2023-04-12 | 2023-06-13 | 45d | 58d |  | Director de Obra; Residente de Obra; Coordinador de Adquisiciones | 564h | 385,601,408 |
| 62 | 3.6.2 | Construcción de pozo de inspección de concreto Para tuberías de diámetro entre los 200 mm (8 pulgadas) y 800 mm (30 pulgadas), diámetro del cilindro 1,20 m. 1,80 m < H < 3,0 m | 30d | 2022-12-21 | 2023-01-31 | 59SS+3d | 2022-12-21 | 2023-01-31 | 30d | 58d | 0d | Residente de Obra; Coordinador de Adquisiciones | 102h | 516,561,493 |
| 63 | 3.6.3 | Construcción de pozo de inspección de concreto Para tuberías de diámetro entre los 200 mm (8 pulgadas) y 800 mm (30 pulgadas), diámetro del cilindro 1,20 m. 3,0 m < H < 5,0 m | 35d | 2023-02-01 | 2023-03-21 | 62 | 2023-02-01 | 2023-03-21 | 35d | 58d | 0d | Residente de Obra; Coordinador de Adquisiciones | 145h | 426,960,000 |
| 64 | 3.6.4 | Tapa de Acero Para Inspección con Cuello en concreto | 22d | 2023-03-22 | 2023-04-20 | 63 | 2023-03-22 | 2023-04-20 | 22d | 96d |  | Residente de Obra; Coordinador de Adquisiciones | 152h | 32,395,544 |
| 65 | 3.6.5 | Box Culvert Principal en Concreto Reforzado 7.0 x 2.5 m | 80d | 2022-10-17 | 2023-02-03 | 52 | 2022-10-17 | 2023-02-03 | 80d | 0d |  | Residente de Obra; Coordinador de Adquisiciones | 594h | 743,276,704 |
| 66 | 3.6.6 | Construccion de Sumidero y Rejilla de Captación Tipo 1 | 30d | 2023-02-06 | 2023-03-17 | 65 | 2023-02-06 | 2023-03-17 | 30d | 0d |  | Director de Obra; Residente de Obra; Coordinador de Adquisiciones | 206h | 702,666,759 |
| 67 | 3.6.7 | Construccion de Disipador de Energia Llegada al Rio | 50d | 2023-03-20 | 2023-05-26 | 68 | 2023-03-20 | 2023-05-26 | 50d | 0d |  | Director de Obra; Coordinador de Adquisiciones | 334h | 189,573,449 |
| 68 | 3.6.8 | Tapas de Acero Para Inspeccion | 30d | 2023-02-06 | 2023-03-17 | 66SS | 2023-02-06 | 2023-03-17 | 30d | 0d |  | Residente de Obra; Coordinador de Adquisiciones | 108h | 19,354,914 |
| 69 | 3.6.9 | Construir muro en gavión tipo INVIAS calibre 2.4 a 2.7 mm con Zinc. Incluye geotextil no tejido tipo macTex® No. 30.1 o similar Para Proteccion del Rio en Estructura de Llegada | 20d | 2023-05-29 | 2023-06-23 | 67 | 2023-05-29 | 2023-06-23 | 20d | 0d |  | Director de Obra; Coordinador de Adquisiciones | 73h | 144,719,435 |
| 70 | 3.6.10 | Protección Marginal de Taludes con colchogaviones tipo INVIAS calibre 2.2 mm con Zinc. E=0.30 mts, incluye colocación de geotextil NT 1400. Para Proteccion del Rio en Estructura de Llegada | 20d | 2023-05-29 | 2023-06-23 | 69SS | 2023-05-29 | 2023-06-23 | 20d | 0d |  | Director de Obra; Residente de Obra; Coordinador de Adquisiciones | 212h | 144,976,196 |

| ID | WBS | Task | Type | Duration | Start | Finish | Predecessors | Baseline start | Baseline finish | Baseline duration | Total slack | Resources | Work | Cost |
| --- | --- | --- | --- | --- | --- | --- | --- | --- | --- | --- | --- | --- | --- | --- |
| 71 | 3.7 | **ESTACIÓN DE BOMBEO** |  | 70d | 2023-05-29 | 2023-09-01 |  | 2023-05-29 | 2023-09-01 | 70d | 0d |  | 905h | 2,111,417,308 |
| 72 | 3.7.1 | Estación de bombeo con capacidad de Q =98,5 lps (Incluye obra civil y suministros para caseta de bombeo, accesorios varios, montaje sistema eléctrico con su certificaco RETIE) |  | 70d | 2023-05-29 | 2023-09-01 | 70SS | 2023-05-29 | 2023-09-01 | 70d | 0d | Director de Obra; Coordinador de Adquisiciones | 905h | 2,111,417,308 |
| 73 | 4 | FIN | milestone | 0d | 2023-09-01 | 2023-09-01 | 72 | 2023-09-01 | 2023-09-01 | 0d | 0d |  |  |  |
